# ISANEProject

Schedule from MS Project, 2008-09-01 to 2011-03-03.

## Calendars

- Estándar: Mon-Fri 09:00-13:00, 15:00-19:00; Sat-Sun off.

## Resources

| Resource |
| --- |
| Director Inserción Profesional |
| Gerente General |
| Director de Mercadeo |
| Equipo de vendedores |
| Secretaria |
| Contable |
| Equipo de profesores |
| Director Inserción Profesional |

## Schedule

| ID | WBS | Task | Duration | Start | Finish | Predecessors | Total slack | Free slack | Constraint | Resources | Work |
| --- | --- | --- | --- | --- | --- | --- | --- | --- | --- | --- | --- |
| 1 | 1 | **A. ETAPA DE ESTABLECIMIENTO** | 131d | 2008-09-01 | 2009-03-02 |  | 1d |  |  |  | 3582h |
| 2 | 1.1 | **1. Creación de la infraestructura inicial** | 65d | 2008-09-01 | 2008-11-28 |  | 1d |  |  |  | 900h |
| 3 | 1.1.1 | **1.1. Preparación del personal** | 65d | 2008-09-01 | 2008-11-28 |  | 1d |  |  |  | 510h |
| 4 | 1.1.1.1 | Contratación Director Inserción Profesional | 15d | 2008-09-01 | 2008-09-19 |  | 1d | 0d | start no earlier than 2008-09-01 | Gerente General [25%] | 30h |
| 5 | 1.1.1.2 | Contratación del Director de Mercadeo, secretaria y contable | 10d | 2008-09-22 | 2008-10-03 | 4 | 1d | 0d | start no earlier than 2008-09-22 | Director Inserción Profesional; Gerente General [50%] | 120h |
| 6 | 1.1.1.3 | Contratación de los vendedores | 10d | 2008-10-06 | 2008-10-17 | 5 | 594d |  | start no earlier than 2008-10-06 | Director de Mercadeo [75%]; Director Inserción Profesional | 120h |
| 7 | 1.1.1.4 | Formación y coordinación del personal | 30d | 2008-10-20 | 2008-11-28 | 6 | 589d |  |  | Director Inserción Profesional | 240h |
| 8 | 1.1.2 | **1.2. Preparación del local** | 45d | 2008-09-01 | 2008-10-31 |  | 609d |  |  |  | 360h |
| 9 | 1.1.2.1 | Búsqueda y adecuación de local provisional | 15d | 2008-09-01 | 2008-09-19 |  | 594d | 0d |  | Gerente General [50%] | 60h |
| 10 | 1.1.2.2 | Búsqueda y contratación del local definitivo | 15d | 2008-09-22 | 2008-10-10 | 9 | 594d |  | start no earlier than 2008-09-22 | Gerente General [50%] | 60h |
| 11 | 1.1.2.3 | Preparación del local definitivo | 15d | 2008-10-13 | 2008-10-31 | 10 | 609d |  |  | Secretaria; Gerente General | 240h |
| 12 | 1.1.3 | **1.3. Otros** | 15d | 2008-09-01 | 2008-09-19 |  | 639d |  |  |  | 30h |
| 13 | 1.1.3.1 | Búsqueda de información y ayuda en la fundación Arrupe | 15d | 2008-09-01 | 2008-09-19 |  | 639d |  |  | Gerente General [25%] | 30h |
| 14 | 1.2 | **2. Preparación de los primeros cursos** | 40d | 2008-10-06 | 2008-11-28 |  | 1d |  |  |  | 570h |
| 15 | 1.2.1 | **2.1. Mercadeo de los primeros cursos** | 40d | 2008-10-06 | 2008-11-28 |  | 1d |  |  |  | 570h |
| 16 | 1.2.1.1 | Creación de estrategia inicial de ventas | 10d | 2008-10-06 | 2008-10-17 | 5 | 1d | 0d | start no earlier than 2008-10-06 | Director de Mercadeo [25%] | 20h |
| 17 | 1.2.1.2 | Publicidad y venta de los primeros cursos | 30d | 2008-10-20 | 2008-11-28 | 16 | 523d | 0d |  | Director de Mercadeo; Equipo de vendedores | 480h |
| 18 | 1.2.1.3 | Creación de la primera versión del sitio Web | 35d | 2008-10-13 | 2008-11-28 |  | 589d |  | start no earlier than 2008-10-13 | Gerente General [25%] | 70h |
| 19 | 1.3 | **3. Comienzo de docencia** | 66d | 2008-12-01 | 2009-03-02 |  | 0d |  |  |  | 2112h |
| 20 | 1.3.1 | **3.1. Docencia de cursos para desempleados** | 66d | 2008-12-01 | 2009-03-02 |  | 523d |  |  |  | 2112h |
| 21 | 1.3.1.1 | Clases de cursos para desempleados | 66d | 2008-12-01 | 2009-03-02 | 17 | 523d |  | start no earlier than 2008-12-01 | Equipo de profesores | 528h |
| 22 | 1.3.1.2 | Soporte de cursos para desempleados | 66d | 2008-12-01 | 2009-03-02 | 17 | 523d |  | start no earlier than 2008-12-01 | Secretaria; Contable | 1056h |
| 23 | 1.3.1.3 | Inserción profesional de los estudiantes de cursos para desempleados | 66d | 2008-12-01 | 2009-03-02 | 17 | 523d |  | start no earlier than 2008-12-01 | Director Inserción Profesional | 528h |
| 24 | 1.3.2 | **3.2. Mercadeo de los cursos de máster** | 66d | 2008-12-01 | 2009-03-02 |  | 0d |  |  |  |  |
| 25 | 1.3.2.1 | Publicidad y venta de cursos de máster | 66d | 2008-12-01 | 2009-03-02 |  | 0d |  | start no earlier than 2008-12-01 |  |  |

| ID | WBS | Task | Duration | Start | Finish | Predecessors | Total slack | Constraint | Resources | Work |
| --- | --- | --- | --- | --- | --- | --- | --- | --- | --- | --- |
| 26 | 2 | **B. ETAPA DE CONSOLIDACIÓN** | 523d | 2009-03-03 | 2011-03-03 |  | 0d |  |  | 29288h |
| 27 | 2.1 | **4. Docencia de máster y otros cursos** | 523d | 2009-03-03 | 2011-03-03 |  | 0d |  |  | 29288h |
| 28 | 2.1.1 | **4.1. Docencia del máster y otros cursos** | 523d | 2009-03-03 | 2011-03-03 |  | 0d |  |  | 20920h |
| 29 | 2.1.1.1 | Clases de máster y otros cursos | 523d | 2009-03-03 | 2011-03-03 | 25 | 0d | finish no earlier than 2011-03-02 | Equipo de profesores | 4184h |
| 30 | 2.1.1.2 | Soporte de máster y otros cursos | 523d | 2009-03-03 | 2011-03-03 | 25 | 0d | start no earlier than 2009-03-02 | Secretaria; Contable | 8368h |
| 31 | 2.1.1.3 | Inserción profesional de los estudiantes de máster y otros cursos | 523d | 2009-03-03 | 2011-03-03 | 25 | 0d | start no earlier than 2009-03-02 | Director Inserción Profesional | 8368h |
| 32 | 2.1.2 | **4.2. Mercadeo de todos los cursos** | 523d | 2009-03-03 | 2011-03-03 |  | 0d |  |  | 8368h |
| 33 | 2.1.2.1 | Publicidad y venta de todos los cursos | 523d | 2009-03-03 | 2011-03-03 | 25 | 0d | start no earlier than 2009-03-02 | Director de Mercadeo; Equipo de vendedores | 8368h |
| 34 | 3 | **C. TAREAS COMUNES A AMBAS ETAPAS** | 618d | 2008-10-20 | 2011-03-02 |  | 1d |  |  | 21506.4h |
| 35 | 3.1 | **5. Tareas permanentes** | 618d | 2008-10-20 | 2011-03-02 |  | 1d |  |  | 21506.4h |
| 36 | 3.1.1 | **5.1. Preparación de cursos** | 618d | 2008-10-20 | 2011-03-02 |  | 1d |  |  | 6674.4h |
| 37 | 3.1.1.1 | Contratación de profesores y otro personal | 618d | 2008-10-20 | 2011-03-02 | 16 | 1d | finish no earlier than 2011-03-02 | Director Inserción Profesional; Gerente General [25%] | 6180h |
| 38 | 3.1.1.2 | Gestión de temarios y contenidos | 618d | 2008-10-20 | 2011-03-02 | 16 | 1d | start no earlier than 2008-10-20 | Gerente General [10%] | 494.4h |
| 39 | 3.1.2 | **5.2. Otras tareas permanentes de soporte** | 618d | 2008-10-20 | 2011-03-02 |  | 1d |  |  | 14832h |
| 40 | 3.1.2.1 | Infraestructuras | 618d | 2008-10-20 | 2011-03-02 | 16 | 1d | finish no earlier than 2011-03-02 | Secretaria; Contable | 9888h |
| 41 | 3.1.2.2 | Dirección de la empresa | 618d | 2008-10-20 | 2011-03-02 | 16 | 1d | start no earlier than 2008-10-20 | Gerente General | 4944h |
